# Presa de Relaves Tambomayo 140505

Schedule from MS Project, 2022-06-12 to 2022-08-25, status date 2020-07-01, 10 hours a day, costs in S..

## Calendars

- QUELLAVECO: Mon-Sun 07:00-12:00, 13:00-18:00.

## Resources

| Resource |
| --- |
| LIMPIEZA |
| REMOCION Y ELIMINACION ROCA FIJA |
| TOP SOIL |
| MATERIAL INADECUADO |
| RELLENO EN DIQUE e=0.5m |
| RELLENO EN DIQUE e=1m |
| RELLENO CON MATERIAL PROPIO EN DIQUE e=0.3m |
| CORTE SIMPLE |
| RELLENO ESTRUCTURAL EN PAD e=0.5m |
| RELLENO ESTRUCTURAL EN PAD e=0.3m |
| BERMA DE SEGURIDAD |
| BASE DE RODADURA e=0.20m |
| EXC. ZANJA SUBDRENAJE |
| CAMA DE APOYO - SBP |
| GEOTEXTIL NO TEJIDO 270 gr/cm2 |
| TUBERIA HDPE PERFORADA |
| RELLENO ZANJA SUBDRENAJE |
| BERMA PERIMETRAL - SBP |
| RELLENO SBP |
| EXC. ZANJA DE ANCLAJE |
| GEOMEMBRANA LLDPE 2mm |
| RELLENO ZANJA ANCLAJE - SBP |
| GRAVA |
| OVER LINER e=0.5m |
| EXCAVACION LOCALIZADA |
| RELLENO ESTRUCTURAL LOCALIZADO |
| CONCRETO |
| Instalación de Tuberías CS 14" |
| Instalación de Tuberías CS 16" |
| EXCAVADORA 336 |
| TRACTOR D8 |
| VOLQUETE |
| RODILLO 19 TON |
| RODILLO 10 TON |
| EXCAVADORA 320 |
| MOTONIVELADORA |
| EXCAVADORA C/MARTILLO |
| ZARANDA ESTÁTICA |
| TRACTOR D6 |
| CARGADOR FRONTAL |
| EXCAVADORA |
| CAMION HIAB 10 TN |
| LUMINARIA |
| MARTILLO HIDRAULICO |
| CISTERNA |
| RETROEXCAVADORA |
| ZARANDA VIBRATORIA |

## Schedule

| ID | WBS | Task | Type | Duration | Start | Finish | Predecessors | Baseline start | Baseline finish | Baseline duration | Total slack | Work | Cost | Baseline cost | Días Calendario |
| --- | --- | --- | --- | --- | --- | --- | --- | --- | --- | --- | --- | --- | --- | --- | --- |
| 1 | 1 | **DEFENSAS RIBEREÑAS DEL RIO LACRAMARCA - PAQUETE R-07** |  | 75d | 2022-06-12 | 2022-08-25 |  |  |  |  | 0d | 10278h | 392,754.5 |  | 75 d |
| 2 | 1.1 | **HITOS** |  | 75d | 2022-06-12 | 2022-08-25 |  |  |  |  | 0d |  |  |  | 75 d |
| 3 | 1.1.1 | Inicio contractual | milestone | 0d | 2022-06-12 | 2022-06-12 |  | 2020-06-05 | 2020-06-11 | 7d | 0d |  |  |  | 0 d |
| 4 | 1.1.2 | Fin proyecto | milestone | 0d | 2022-08-25 | 2022-08-25 | 91 | 2020-06-05 | 2020-06-11 | 7d | 0d |  |  |  | 0 d |
| 5 | 1.2 | **ACTIVIDADES PRE-CONSTRUCCION** |  | 30d | 2022-06-12 | 2022-07-11 |  |  |  |  | 0d |  | 392,754.5 |  | 30 d |
| 6 | 1.2.1 | **LEGAL** |  | 7d | 2022-06-12 | 2022-06-18 |  | 2020-06-05 | 2020-06-11 | 7d | 0d |  |  |  | 7 d |
| 7 | 1.2.1.1 | Revisión de Contrato y Anexos |  | 7d | 2022-06-12 | 2022-06-18 | 3 | 2020-06-05 | 2020-06-11 | 7d | 0d |  |  |  | 7 d |
| 8 | 1.2.2 | **PLANES DE GESTION** |  | 7d | 2022-06-12 | 2022-06-18 |  | 2020-06-05 | 2020-06-11 | 7d | 0d |  |  |  | 7 d |
| 9 | 1.2.2.1 | Elaboración Planes de gestión |  | 7d | 2022-06-12 | 2022-06-18 | 7SS | 2020-06-05 | 2020-06-11 | 7d | 0d |  |  |  | 7 d |
| 10 | 1.2.2.2 | Aprobación de planes de gestión |  | 7d | 2022-06-12 | 2022-06-18 | 7SS | 2020-06-05 | 2020-06-11 | 7d | 0d |  |  |  | 7 d |
| 11 | 1.2.3 | **GESTIÓN DEL PERSONAL** |  | 21d | 2022-06-12 | 2022-07-02 |  | 2020-06-05 | 2020-06-23 | 19d | 0d |  |  |  | 21 d |
| 12 | 1.2.3.1 | Reclutamiento Personal Empleado |  | 5d | 2022-06-12 | 2022-06-16 | 7SS, 9SS, 10SS | 2020-06-05 | 2020-06-09 | 5d | 0d |  |  |  | 5 d |
| 13 | 1.2.3.2 | Reclutamiento Personal Obrero |  | 5d | 2022-06-12 | 2022-06-16 | 12SS | 2020-06-05 | 2020-06-09 | 5d | 0d |  |  |  | 5 d |
| 14 | 1.2.3.3 | Exámenes Médicos |  | 8d | 2022-06-16 | 2022-06-23 | 12SS+4d, 13SS+4d | 2020-06-09 | 2020-06-13 | 5d | 0d |  |  |  | 8 d |
| 15 | 1.2.3.4 | Inducción en Obra |  | 3d | 2022-06-24 | 2022-06-26 | 14 | 2020-06-14 | 2020-06-17 | 4d | 0d |  |  |  | 3 d |
| 16 | 1.2.3.5 | Autorización de Fotocheck |  | 3d | 2022-06-27 | 2022-06-29 | 15 | 2020-06-18 | 2020-06-20 | 3d | 0d |  |  |  | 3 d |
| 17 | 1.2.3.6 | Certificación de Operadores |  | 3d | 2022-06-30 | 2022-07-02 | 16 | 2020-06-21 | 2020-06-23 | 3d | 0d |  |  |  | 3 d |
| 18 | 1.2.4 | **GESTIÓN DE EQUIPOS** |  | 30d | 2022-06-12 | 2022-07-11 |  | 2020-06-05 | 2020-06-28 | 24d | 0d |  | 392,754.5 | 392,754.5 | 30 d |
| 19 | 1.2.4.1 | O/C Alquiler de equipos |  | 6d | 2022-06-12 | 2022-06-17 | 9SS, 3SS | 2020-06-05 | 2020-06-09 | 5d | 0d |  |  |  | 6 d |
| 20 | 1.2.4.2 | Revisión Técnica |  | 6d | 2022-06-18 | 2022-06-23 | 19 | 2020-06-10 | 2020-06-16 | 7d | 0d |  |  |  | 6 d |
| 21 | 1.2.4.3 | Aprobación de Equipos |  | 6d | 2022-06-24 | 2022-06-29 | 20 | 2020-06-17 | 2020-06-21 | 5d | 0d |  |  |  | 6 d |
| 22 | 1.2.4.4 | Movilización de Equipos |  | 12d | 2022-06-30 | 2022-07-11 | 21 | 2020-06-22 | 2020-06-28 | 7d | 0d |  | 392,754.5 | 392,754.5 | 12 d |
| 23 | 1.2.5 | **INSTALACIONES TEMPORALES** |  | 12d | 2022-06-30 | 2022-07-11 |  | 2020-06-21 | 2020-06-30 | 10d | 0d |  |  |  | 12 d |
| 24 | 1.2.5.1 | Instalación de Facilidades |  | 12d | 2022-06-30 | 2022-07-11 | 17SS | 2020-06-21 | 2020-06-30 | 10d | 0d |  |  |  | 12 d |

| ID | WBS | Task | Type | Duration | Start | Finish | Predecessors | Total slack | Resources | Work | Días Calendario | Frente | WBS (Cliente) |
| --- | --- | --- | --- | --- | --- | --- | --- | --- | --- | --- | --- | --- | --- |
| 25 | 1.3 | **ACTIVIDADES CONSTRUCCIÓN** |  | 50d | 2022-07-07 | 2022-08-25 |  | 0d |  | 7038h | 50 d |  |  |
| 26 | 1.3.1 | **FRENTE 01** |  | 50d | 2022-07-07 | 2022-08-25 |  | 0d |  | 2380h | 50 d |  |  |
| 27 | 1.3.1.1 | **Protección de dique existente con enrocado A4.2-2-MI** |  | 21d | 2022-07-07 | 2022-07-27 |  | 0d |  | 1136h | 21 d |  |  |
| 28 | 1.3.1.1.1 | DESBROCE Y LIMPIEZA EN ZONA NO BOSCOSA |  | 2d | 2022-07-07 | 2022-07-08 | 22SS+7d, 24SS+7d | 0d | TOP SOIL; TRACTOR D6 [200%]; LUMINARIA [150%]; EXCAVADORA 336 [130%]; VOLQUETE [600%] | 216h | 2 d | m2 | CE261215 |
| 29 | 1.3.1.1.2 | EXCAVACIÓN EN MATERIAL SUELTO CON EQUIPO |  | 5d | 2022-07-09 | 2022-07-13 | 28 | 0d | MATERIAL INADECUADO; VOLQUETE [400%]; TRACTOR D6; TRACTOR D8; EXCAVADORA 336 [150%]; LUMINARIA [150%] | 450h | 5 d | m3 | CE261215 |
| 30 | 1.3.1.1.3 | PERFILADO Y COMPACTACIÓN EN ZONA DE CORTE |  | 3d | 2022-07-14 | 2022-07-16 | 29 | 0d | CORTE SIMPLE; TRACTOR D8; EXCAVADORA 336 [150%]; VOLQUETE [400%]; TRACTOR D6; LUMINARIA [150%] | 270h | 3 d | m2 | CE261215 |
| 31 | 1.3.1.1.4 | GEOTEXTIL NO TEJIDO 400 gr/m2, INC. COLOCACIÓN |  | 2d | 2022-07-17 | 2022-07-18 | 30 | 0d |  |  | 2 d | m2 |  |
| 32 | 1.3.1.1.5 | CAMA DE APOYO (e=0.25 m) |  | 2d | 2022-07-19 | 2022-07-20 | 31 | 0d | EXCAVADORA 336 [150%]; TRACTOR D8; VOLQUETE [400%]; TRACTOR D6; MARTILLO HIDRAULICO; LUMINARIA [150%] | 200h | 2 d | m3 |  |
| 33 | 1.3.1.1.6 | COLOCACIÓN Y ACOMODO DE ROCA EN UÑA DEL DIQUE |  | 3d | 2022-07-21 | 2022-07-23 | 32 | 0d |  |  | 3 d | m3 |  |
| 34 | 1.3.1.1.7 | COLOCACIÓN Y ACOMODO DE ROCA EN TALUD DEL DIQUE |  | 4d | 2022-07-24 | 2022-07-27 | 33 | 0d |  |  | 4 d | m3 |  |
| 35 | 1.3.1.2 | **Construcción de Nuevo dique de tierra más enrococado A4.2-1-MD** |  | 14d | 2022-07-28 | 2022-08-10 |  | 0d |  | 100h | 14 d |  |  |
| 36 | 1.3.1.2.1 | **DIQUE DE TIERRA COMPACTADA** |  | 8d | 2022-07-28 | 2022-08-04 |  | 0d |  |  | 8 d |  |  |
| 37 | 1.3.1.2.1.1 | DESBROCE Y LIMPIEZA EN ZONA NO BOSCOSA |  | 1d | 2022-07-28 | 2022-07-28 | 34 | 0d |  |  | 1 d | m2 |  |
| 38 | 1.3.1.2.1.2 | EXCAVACIÓN EN MATERIAL SUELTO CON EQUIPO |  | 2d | 2022-07-29 | 2022-07-30 | 37 | 0d |  |  | 2 d | m3 |  |
| 39 | 1.3.1.2.1.3 | PERFILADO Y COMPACTACIÓN EN ZONA DE CORTE |  | 1d | 2022-07-31 | 2022-07-31 | 38 | 0d |  |  | 1 d | m2 |  |
| 40 | 1.3.1.2.1.4 | CONFORMACIÓN DE CUERPO DEL DIQUE |  | 3d | 2022-08-01 | 2022-08-03 | 39 | 0d |  |  | 3 d | m3 |  |
| 41 | 1.3.1.2.1.5 | CONFORMACIÓN DE MATERIAL GRANULAR EN CORONA DEL DIQUE |  | 1d | 2022-08-04 | 2022-08-04 | 40 | 0d |  |  | 1 d | m3 |  |
| 42 | 1.3.1.2.2 | **ENROCADO CON PIEDRA ACOMODADA** |  | 6d | 2022-08-04 | 2022-08-10 |  | 0d |  | 100h | 7 d |  |  |
| 43 | 1.3.1.2.2.1 | DESBROCE Y LIMPIEZA EN ZONA NO BOSCOSA | milestone | 0d | 2022-08-04 | 2022-08-04 | 41 | 0d | TOP SOIL; TRACTOR D6 [200%]; LUMINARIA [150%]; EXCAVADORA 336 [130%]; VOLQUETE [600%] |  | 0 d | m2 | CE261215 |
| 44 | 1.3.1.2.2.2 | EXCAVACIÓN EN MATERIAL SUELTO CON EQUIPO | milestone | 0d | 2022-08-04 | 2022-08-04 | 43 | 0d | MATERIAL INADECUADO; VOLQUETE [400%]; TRACTOR D6; TRACTOR D8; EXCAVADORA 336 [150%]; LUMINARIA [150%] |  | 0 d | m3 | CE261215 |
| 45 | 1.3.1.2.2.3 | PERFILADO Y COMPACTACIÓN EN ZONA DE CORTE | milestone | 0d | 2022-08-04 | 2022-08-04 | 44 | 0d | CORTE SIMPLE; TRACTOR D8; EXCAVADORA 336 [150%]; VOLQUETE [400%]; TRACTOR D6; LUMINARIA [150%] |  | 0 d | m2 | CE261215 |
| 46 | 1.3.1.2.2.4 | GEOTEXTIL NO TEJIDO 400 gr/m2, INC. COLOCACIÓN |  | 1d | 2022-08-05 | 2022-08-05 | 45 | 0d |  |  | 1 d | m2 |  |
| 47 | 1.3.1.2.2.5 | CAMA DE APOYO (e=0.25 m) |  | 1d | 2022-08-06 | 2022-08-06 | 46 | 0d | EXCAVADORA 336 [150%]; TRACTOR D8; VOLQUETE [400%]; TRACTOR D6; MARTILLO HIDRAULICO; LUMINARIA [150%] | 100h | 1 d | m3 |  |
| 48 | 1.3.1.2.2.6 | COLOCACIÓN Y ACOMODO DE ROCA EN UÑA DEL DIQUE |  | 2d | 2022-08-07 | 2022-08-08 | 47 | 0d |  |  | 2 d | m3 |  |
| 49 | 1.3.1.2.2.7 | COLOCACIÓN Y ACOMODO DE ROCA EN TALUD DEL DIQUE |  | 2d | 2022-08-09 | 2022-08-10 | 48 | 0d |  |  | 2 d | m3 |  |

| ID | WBS | Task | Type | Duration | Start | Finish | Predecessors | Total slack | Free slack | Resources | Work | Días Calendario | Frente | WBS (Cliente) |
| --- | --- | --- | --- | --- | --- | --- | --- | --- | --- | --- | --- | --- | --- | --- |
| 50 | 1.3.1.3 | **Protección de dique existente con enrocado A4.2-1-MD** |  | 7d | 2022-08-11 | 2022-08-17 |  | 0d |  |  | 388h | 7 d |  |  |
| 51 | 1.3.1.3.1 | DESBROCE Y LIMPIEZA EN ZONA NO BOSCOSA |  | 1d | 2022-08-11 | 2022-08-11 | 49 | 0d |  | TOP SOIL; TRACTOR D6 [200%]; LUMINARIA [150%]; EXCAVADORA 336 [130%]; VOLQUETE [600%] | 108h | 1 d | m2 | CE261215 |
| 52 | 1.3.1.3.2 | EXCAVACIÓN EN MATERIAL SUELTO CON EQUIPO |  | 1d | 2022-08-12 | 2022-08-12 | 51 | 0d |  | MATERIAL INADECUADO; VOLQUETE [400%]; TRACTOR D6; TRACTOR D8; EXCAVADORA 336 [150%]; LUMINARIA [150%] | 90h | 1 d | m3 | CE261215 |
| 53 | 1.3.1.3.3 | PERFILADO Y COMPACTACIÓN EN ZONA DE CORTE |  | 1d | 2022-08-13 | 2022-08-13 | 52 | 0d |  | CORTE SIMPLE; TRACTOR D8; EXCAVADORA 336 [150%]; VOLQUETE [400%]; TRACTOR D6; LUMINARIA [150%] | 90h | 1 d | m2 | CE261215 |
| 54 | 1.3.1.3.4 | GEOTEXTIL NO TEJIDO 400 gr/m2, INC. COLOCACIÓN |  | 1d | 2022-08-14 | 2022-08-14 | 53 | 0d |  |  |  | 1 d | m2 |  |
| 55 | 1.3.1.3.5 | CAMA DE APOYO (e=0.25 m) |  | 1d | 2022-08-15 | 2022-08-15 | 54 | 0d |  | EXCAVADORA 336 [150%]; TRACTOR D8; VOLQUETE [400%]; TRACTOR D6; MARTILLO HIDRAULICO; LUMINARIA [150%] | 100h | 1 d | m3 |  |
| 56 | 1.3.1.3.6 | COLOCACIÓN Y ACOMODO DE ROCA EN UÑA DEL DIQUE |  | 1d | 2022-08-16 | 2022-08-16 | 55 | 0d |  |  |  | 1 d | m3 |  |
| 57 | 1.3.1.3.7 | COLOCACIÓN Y ACOMODO DE ROCA EN TALUD DEL DIQUE |  | 1d | 2022-08-17 | 2022-08-17 | 56 | 0d |  |  |  | 1 d | m3 |  |
| 58 | 1.3.1.4 | **Protección de Cauce (Cauce y cimentación de Acueducto)** |  | 8d | 2022-08-18 | 2022-08-25 |  | 0d |  |  | 756h | 8 d |  |  |
| 59 | 1.3.1.4.1 | EXCAVACIÓN EN MATERIAL SUELTO CON EQUIPO |  | 2d | 2022-08-18 | 2022-08-19 | 57 | 0d |  | TOP SOIL; TRACTOR D6 [200%]; LUMINARIA [150%]; EXCAVADORA 336 [130%]; VOLQUETE [600%] | 216h | 2 d | m3 | CE261215 |
| 60 | 1.3.1.4.2 | PERFILADO Y COMPACTACIÓN CON EQUIPO DE FONDO DE EXCAVACIÓN |  | 1d | 2022-08-20 | 2022-08-20 | 59 | 0d |  | MATERIAL INADECUADO; VOLQUETE [400%]; TRACTOR D6; TRACTOR D8; EXCAVADORA 336 [150%]; LUMINARIA [150%] | 90h | 1 d | m2 | CE261215 |
| 61 | 1.3.1.4.3 | COLOCACIÓN DE ROCA EN CAUCE |  | 5d | 2022-08-21 | 2022-08-25 | 60 | 0d |  | CORTE SIMPLE; TRACTOR D8; EXCAVADORA 336 [150%]; VOLQUETE [400%]; TRACTOR D6; LUMINARIA [150%] | 450h | 5 d | m3 | CE261215 |
| 62 | 1.3.2 | **FRENTE 02** |  | 41d | 2022-07-12 | 2022-08-21 |  | 4d |  |  | 788h | 41 d |  |  |
| 63 | 1.3.2.1 | **Construcción de Nuevo dique de tierra más enrococado A4.2-2-MD** |  | 35d | 2022-07-12 | 2022-08-15 |  | 4d |  |  | 300h | 35 d |  |  |
| 64 | 1.3.2.1.1 | **DIQUE DE TIERRA COMPACTADA** |  | 19d | 2022-07-12 | 2022-07-30 |  | 4d |  |  |  | 19 d |  |  |
| 65 | 1.3.2.1.1.1 | DESBROCE Y LIMPIEZA EN ZONA NO BOSCOSA |  | 3d | 2022-07-12 | 2022-07-14 | 22, 24 | 4d | 0d |  |  | 3 d | m2 |  |
| 66 | 1.3.2.1.1.2 | EXCAVACIÓN EN MATERIAL SUELTO CON EQUIPO |  | 5d | 2022-07-15 | 2022-07-19 | 65 | 4d | 0d |  |  | 5 d | m3 |  |
| 67 | 1.3.2.1.1.3 | PERFILADO Y COMPACTACIÓN EN ZONA DE CORTE |  | 2d | 2022-07-20 | 2022-07-21 | 66 | 4d | 0d |  |  | 2 d | m2 |  |
| 68 | 1.3.2.1.1.4 | CONFORMACIÓN DE CUERPO DEL DIQUE |  | 7d | 2022-07-22 | 2022-07-28 | 67 | 4d | 0d |  |  | 7 d | m3 |  |
| 69 | 1.3.2.1.1.5 | CONFORMACIÓN DE MATERIAL GRANULAR EN CORONA DEL DIQUE |  | 2d | 2022-07-29 | 2022-07-30 | 68 | 4d | 0d |  |  | 2 d | m3 |  |
| 70 | 1.3.2.1.2 | **ENROCADO CON PIEDRA ACOMODADA** |  | 16d | 2022-07-30 | 2022-08-15 |  | 4d |  |  | 300h | 17 d |  |  |
| 71 | 1.3.2.1.2.1 | DESBROCE Y LIMPIEZA EN ZONA NO BOSCOSA | milestone | 0d | 2022-07-30 | 2022-07-30 | 69 | 4d | 0d | TOP SOIL; TRACTOR D6 [200%]; LUMINARIA [150%]; EXCAVADORA 336 [130%]; VOLQUETE [600%] |  | 0 d | m2 | CE261215 |
| 72 | 1.3.2.1.2.2 | EXCAVACIÓN EN MATERIAL SUELTO CON EQUIPO | milestone | 0d | 2022-07-30 | 2022-07-30 | 71 | 4d | 0d | MATERIAL INADECUADO; VOLQUETE [400%]; TRACTOR D6; TRACTOR D8; EXCAVADORA 336 [150%]; LUMINARIA [150%] |  | 0 d | m3 | CE261215 |
| 73 | 1.3.2.1.2.3 | PERFILADO Y COMPACTACIÓN EN ZONA DE CORTE | milestone | 0d | 2022-07-30 | 2022-07-30 | 72 | 4d | 0d | CORTE SIMPLE; TRACTOR D8; EXCAVADORA 336 [150%]; VOLQUETE [400%]; TRACTOR D6; LUMINARIA [150%] |  | 0 d | m2 | CE261215 |
| 74 | 1.3.2.1.2.4 | GEOTEXTIL NO TEJIDO 400 gr/m2, INC. COLOCACIÓN |  | 3d | 2022-07-31 | 2022-08-02 | 73 | 4d | 0d |  |  | 3 d | m2 |  |
| 75 | 1.3.2.1.2.5 | CAMA DE APOYO (e=0.25 m) |  | 3d | 2022-08-03 | 2022-08-05 | 74 | 4d | 0d | EXCAVADORA 336 [150%]; TRACTOR D8; VOLQUETE [400%]; TRACTOR D6; MARTILLO HIDRAULICO; LUMINARIA [150%] | 300h | 3 d | m3 |  |
| 76 | 1.3.2.1.2.6 | COLOCACIÓN Y ACOMODO DE ROCA EN UÑA DEL DIQUE |  | 4d | 2022-08-06 | 2022-08-09 | 75 | 4d | 0d |  |  | 4 d | m3 |  |
| 77 | 1.3.2.1.2.7 | COLOCACIÓN Y ACOMODO DE ROCA EN TALUD DEL DIQUE |  | 6d | 2022-08-10 | 2022-08-15 | 76 | 4d | 0d |  |  | 6 d | m3 |  |

| ID | WBS | Task | Duration | Start | Finish | Predecessors | Total slack | Free slack | Resources | Work | Días Calendario | Frente | WBS (Cliente) |
| --- | --- | --- | --- | --- | --- | --- | --- | --- | --- | --- | --- | --- | --- |
| 78 | 1.3.2.2 | **Desvío de camino existente (Camino Proyectado)** | 6d | 2022-08-16 | 2022-08-21 |  | 4d |  |  | 488h | 6 d |  |  |
| 79 | 1.3.2.2.1 | DESBROCE Y LIMPIEZA EN ZONA NO BOSCOSA | 1d | 2022-08-16 | 2022-08-16 | 77 | 4d | 0d | TOP SOIL; TRACTOR D6 [200%]; LUMINARIA [150%]; EXCAVADORA 336 [130%]; VOLQUETE [600%] | 108h | 1 d | m2 | CE261215 |
| 80 | 1.3.2.2.2 | EXCAVACIÓN EN MATERIAL SUELTO CON EQUIPO | 1d | 2022-08-17 | 2022-08-17 | 79 | 4d | 0d | MATERIAL INADECUADO; VOLQUETE [400%]; TRACTOR D6; TRACTOR D8; EXCAVADORA 336 [150%]; LUMINARIA [150%] | 90h | 1 d | m3 | CE261215 |
| 81 | 1.3.2.2.3 | PERFILADO Y COMPACTACIÓN EN ZONA DE CORTE | 1d | 2022-08-18 | 2022-08-18 | 80 | 4d | 0d | CORTE SIMPLE; TRACTOR D8; EXCAVADORA 336 [150%]; VOLQUETE [400%]; TRACTOR D6; LUMINARIA [150%] | 90h | 1 d | m2 | CE261215 |
| 82 | 1.3.2.2.4 | CONFORMACIÓN DE TERRAPLEN EN CAMINO | 1d | 2022-08-19 | 2022-08-19 | 81 | 4d | 0d |  |  | 1 d | m3 |  |
| 83 | 1.3.2.2.5 | MATERIAL AFIRMADO e=0.30 m | 2d | 2022-08-20 | 2022-08-21 | 82 | 4d |  | EXCAVADORA 336 [150%]; TRACTOR D8; VOLQUETE [400%]; TRACTOR D6; MARTILLO HIDRAULICO; LUMINARIA [150%] | 200h | 2 d | m3 |  |
| 84 | 1.3.3 | **FRENTE 03** | 50d | 2022-07-07 | 2022-08-25 |  | 0d |  |  | 3870h | 50 d |  |  |
| 85 | 1.3.3.1 | ACONDICIONAMIENTO DE DEPÓSITOS DE MATERIALES EXCEDENTES (DME) | 36d | 2022-07-12 | 2022-08-16 | 22, 24 | 2d | 0d | MATERIAL INADECUADO; VOLQUETE [400%]; TRACTOR D6; TRACTOR D8; EXCAVADORA 336 [150%]; LUMINARIA [150%] | 3240h | 36 d | m3 | CE261215 |
| 86 | 1.3.3.2 | RESTAURACIÓN DE ÁREAS DE INSTALACIONES PROVISIONALES | 7d | 2022-08-17 | 2022-08-23 | 85 | 2d |  | CORTE SIMPLE; TRACTOR D8; EXCAVADORA 336 [150%]; VOLQUETE [400%]; TRACTOR D6; LUMINARIA [150%] | 630h | 7 d | m2 | CE261215 |
| 87 | 1.3.3.3 | PROGRAMA DE MONITOREO AMBIENTAL | 50d | 2022-07-07 | 2022-08-25 | 28SS | 0d |  |  |  | 50 d | pto |  |
| 88 | 1.4 | **ACTIVIDADES POST - CONSTRUCCIÓN** | 15d | 2022-08-11 | 2022-08-25 |  | 0d |  |  | 3240h | 15 d |  |  |
| 89 | 1.4.1 | **DESMOVILIZACION DE EQUIPOS Y PERSONAL** | 15d | 2022-08-11 | 2022-08-25 |  | 0d |  |  | 3240h | 15 d |  |  |
| 90 | 1.4.1.1 | DESMOVILIZACION DE EQUIPOS Y HERRAMIENTAS | 15d | 2022-08-11 | 2022-08-25 | 51SS | 0d |  | TOP SOIL; TRACTOR D6 [200%]; LUMINARIA [150%]; EXCAVADORA 336 [130%]; VOLQUETE [600%] | 1620h | 15 d | m2 | CE261215 |
| 91 | 1.4.1.2 | DESMOVILIZACION DE PERSONAL | 15d | 2022-08-11 | 2022-08-25 | 90SS | 0d |  | TOP SOIL; TRACTOR D6 [200%]; LUMINARIA [150%]; EXCAVADORA 336 [130%]; VOLQUETE [600%] | 1620h | 15 d | m2 | CE261215 |
